# План-график

Schedule from MS Project, 2024-11-14 to 2025-04-22, A marks actual dates.

## Calendars

- Стандартный: Mon-Fri 09:00-13:00, 14:00-18:00; Sat-Sun off.

## Resources

| Resource |
| --- |
| Заказчик |
| Исполнитель |
| Руководитель проекта |

## Schedule

| ID | WBS | Task | Duration | Start | Finish | Predecessors | Complete | Remaining | Total slack | Free slack | Constraint | Resources | Work | Actual work |
| --- | --- | --- | --- | --- | --- | --- | --- | --- | --- | --- | --- | --- | --- | --- |
| 1 | 1 | Подписание договора | 1d | 2024-11-14 | 2024-11-14 |  |  |  | 113d |  | start no earlier than 2024-11-14 | Заказчик; Исполнитель | 16h |  |
| 2 | 2 | **Этап 1. Обследование и поставка оборудования** | 31d | 2024-11-14 | 2024-12-26 |  |  |  | 20d |  |  |  | 376h |  |
| 3 | 2.1 | Отправка Письма о начале работ по этапу (Количество писем - уведомлений ограничено Общей стоимостью настоящего Договора, указанной в Приложении № 1 к настоящему Договору) | 1d | 2024-11-14 | 2024-11-14 |  |  |  | 20d | 0d | start no earlier than 2024-11-14 | Заказчик | 8h |  |
| 4 | 2.2 | Проведение обследования Объектов | 10d | 2024-11-15 | 2024-11-28 | 3 |  |  | 20d | 0d |  | Исполнитель | 80h |  |
| 5 | 2.3 | Разработка Проектной документации | 10d | 2024-11-29 | 2024-12-12 | 4 |  |  | 20d | 0d |  | Исполнитель | 80h |  |
| 6 | 2.4 | Согласование Проектной документации | 10d | 2024-12-13 | 2024-12-26 | 5 |  |  | 20d |  |  | Заказчик; Исполнитель | 160h |  |
| 7 | 2.5 | Отправка письма-запроса требований к тестовому стенду и требования и ограничения подключения системы на продуктивном сервер | 1d | 2024-11-14 | 2024-11-14 |  |  |  | 108d | 0d | start no earlier than 2024-11-14 | Заказчик | 8h |  |
| 8 | 2.6 | Предоставление требования к тестовому стенду и данных для подключения | 5d | 2024-11-15 | 2024-11-21 | 7 |  |  | 108d |  |  | Исполнитель | 40h |  |
| 9 | 3 | **Этап 2. Поставка ПАК** | 83d | 2024-11-14 A | 2025-03-10 |  | 1% | 82d | 31d |  |  |  | 680h | 8h |
| 10 | 3.1 | Отправка Письма о начале поставки оборудования по этапу (Количество писем - уведомлений ограничено Общей стоимостью настоящего Договора, указанной в Приложении № 1 к настоящему Договору) | 1d | 2024-11-14 A | 2024-11-14 A |  | 100% |  |  |  |  | Заказчик | 8h | 8h |
| 11 | 3.2 | Поставка ПАК ЦПИУ "Рубеж" | 40d | 2024-11-15 | 2025-01-09 | 10 |  |  | 31d | 0d |  | Исполнитель | 320h |  |
| 12 | 3.3 | Приемка, подписание товарной накладной (ТОРГ-12) / УПД | 2d | 2025-01-10 | 2025-01-13 | 11 |  |  | 31d | 0d |  | Заказчик; Исполнитель | 32h |  |
| 13 | 3.4 | Оплата за ПАК | 40d | 2025-01-14 | 2025-03-10 | 12 |  |  | 31d |  |  | Заказчик | 320h |  |
| 14 | 4 | **Этап 3. Монтаж и пусконаладка Оборудования** | 114d | 2024-11-14 | 2025-04-22 |  |  |  | 0d |  |  |  | 1448h |  |
| 15 | 4.1 | Отправка Письма о начале работ по этапу (Количество писем - уведомлений ограничено Общей стоимостью настоящего Договора, указанной в Приложении № 1 к настоящему Договору) | 1d | 2024-11-14 | 2024-11-14 |  |  |  | 0d |  | start no earlier than 2024-11-14 | Заказчик | 8h |  |
| 16 | 4.2 | Подписание акта передачи оборудования в монтаж (ОС-15) | 5d | 2024-11-15 | 2024-11-21 | 15 |  |  | 0d |  |  | Заказчик; Исполнитель | 80h |  |
| 17 | 4.3 | Установка/монтаж оборудования ЦПИУ "Рубеж" | 20d | 2024-11-22 | 2024-12-19 | 16 |  |  | 0d |  |  | Исполнитель | 160h |  |
| 18 | 4.4 | Подключение и пусконаладка Оборудования | 10d | 2024-12-20 | 2025-01-02 | 17 |  |  | 0d |  |  | Исполнитель | 80h |  |
| 19 | 4.5 | **Внедрение системы и приемочные испытания** | 50d | 2024-11-15 | 2025-01-23 |  |  |  | 0d |  |  |  | 616h |  |
| 20 | 4.5.1 | Установка и настройка системы на серверах | 5d | 2024-11-15 | 2024-11-21 | 15 |  |  | 10d | 0d | start no earlier than 2024-11-14 | Исполнитель | 40h |  |
| 21 | 4.5.2 | Тестирование на виртуальном стенде | 5d | 2024-11-22 | 2024-11-28 | 20 |  |  | 10d | 0d |  | Исполнитель; Заказчик | 80h |  |
| 22 | 4.5.3 | Разработка эксплуатационной документации | 10d | 2024-11-29 | 2024-12-12 | 21 |  |  | 10d | 0d |  | Исполнитель | 80h |  |
| 23 | 4.5.4 | Согласование эксплуатационной документации | 10d | 2024-12-13 | 2024-12-26 | 22 |  |  | 10d |  |  | Заказчик; Исполнитель | 160h |  |
| 24 | 4.5.5 | Предоставление инструкции по установке обновления | 2d | 2024-11-29 | 2024-12-02 | 21 |  |  | 23d |  |  | Исполнитель | 16h |  |
| 25 | 4.5.6 | Приемочные испытания | 5d | 2025-01-03 | 2025-01-09 | 24, 18 |  |  | 0d |  |  | Исполнитель; Заказчик | 80h |  |

Notes:
- 22: Условия, при которых включается в ПГ: В случае необходимости внешней разработки

| ID | WBS | Task | Duration | Start | Finish | Predecessors | Total slack | Resources | Work |
| --- | --- | --- | --- | --- | --- | --- | --- | --- | --- |
| 26 | 4.5.7 | **Приемка системы в эксплуатацию** | 10d | 2025-01-10 | 2025-01-23 |  | 0d |  | 160h |
| 27 | 4.5.7.1 | Передача системы в опытную эксплуатацию | 10d | 2025-01-10 | 2025-01-23 | 18, 25, 23 | 0d | Заказчик; Исполнитель | 160h |
| 28 | 4.6 | Подписание Акта выполненных работ | 20d | 2025-01-24 | 2025-02-20 | 27, 6 | 0d | Заказчик | 160h |
| 29 | 4.7 | Подписание Акта выполненных работ | 3d | 2025-02-21 | 2025-02-25 | 28 | 0d | Исполнитель | 24h |
| 30 | 4.8 | Оплата | 40d | 2025-02-26 | 2025-04-22 | 29, 28 | 0d | Заказчик | 320h |
